# Program Kerja Fasa Pra-Pembinaan PAP (Tanpa Pindaan)

Schedule from MS Project, 2018-01-01 to 2018-08-30.
Unit Amalan Terbaik, BPPK, CPAB

## Calendars

- Standard: Mon-Fri 08:00-12:00, 13:00-17:00; Sat-Sun off.

## Schedule

| ID | WBS | Task | Type | Duration | Start | Finish | Predecessors | Total slack | Free slack |
| --- | --- | --- | --- | --- | --- | --- | --- | --- | --- |
| 1 | 1 | **Program Kerja Fasa Pra-Pembinaan Reka dan Bina** |  | 174d | 2018-01-01 | 2018-08-30 |  | 0d |  |
| 2 | 1.1 | Mula Pembinaan | milestone | 0d | 2018-01-01 | 2018-01-01 |  | 0d |  |
| 3 | 1.2 | **Perancangan Pelaksanaan Projek** |  | 57d | 2018-01-01 | 2018-03-20 |  | 0d |  |
| 4 | 1.2.1 | Rancang Strategi Pelaksanaan |  | 1d | 2018-01-01 | 2018-01-01 | 2 | 0d |  |
| 5 | 1.2.2 | Terima Arahan Pelaksanaan dan Brif Projek |  | 3d | 2018-01-02 | 2018-01-04 | 4 | 0d |  |
| 6 | 1.2.3 | Lantik HOPT |  | 1d | 2018-01-05 | 2018-01-05 | 5 | 0d |  |
| 7 | 1.2.4 | Laksana ACAT |  | 1d | 2018-01-08 | 2018-01-08 | 6 | 0d |  |
| 8 | 1.2.5 | Lantik HODT |  | 1d | 2018-01-09 | 2018-01-09 | 7 | 0d |  |
| 9 | 1.2.6 | Laksana GN1 |  | 1d | 2018-01-10 | 2018-01-10 | 8 | 0d |  |
| 10 | 1.2.7 | Laksana Semakan Brif 01-1, Verifikasi Harta Pelanggan dan Analisis Sumber Manusia |  | 3d | 2018-01-11 | 2018-01-15 | 9 | 0d |  |
| 11 | 1.2.8 | Sedia Rekabentuk Konsep dan Dokumen Tender |  | 25d | 2018-01-16 | 2018-02-19 | 10 | 0d |  |
| 12 | 1.2.9 | Sedia Kos Anggaran Awalan |  | 3d | 2018-02-20 | 2018-02-22 | 11 | 0d |  |
| 13 | 1.2.10 | Sedia Pelan Kualiti / RMP |  | 3d | 2018-02-20 | 2018-02-22 | 11 | 16d | 0d |
| 14 | 1.2.11 | Kajian Semula Rekabentuk Konsep |  | 3d | 2018-02-20 | 2018-02-22 | 11 | 0d |  |
| 15 | 1.2.12 | Laksana VE |  | 5d | 2018-02-23 | 2018-03-01 | 12, 14 | 0d |  |
| 16 | 1.2.13 | Pengesahan Brif Projek, Rekabentuk Konsep dan Kos Awalan |  | 1d | 2018-03-16 | 2018-03-16 | 15FS+10d | 0d |  |
| 17 | 1.2.14 | Pendaftaran Maklumat dalam SKALA |  | 1d | 2018-03-19 | 2018-03-19 | 13, 16 | 0d |  |
| 18 | 1.2.15 | Laksana GN3 |  | 1d | 2018-03-20 | 2018-03-20 | 17 | 0d |  |
| 19 | 1.2.16 | Siap Perancangan | milestone | 0d | 2018-03-20 | 2018-03-20 | 18 | 0d |  |
| 20 | 1.3 | **Perolehan** |  | 117d | 2018-03-21 | 2018-08-30 |  | 0d |  |
| 21 | 1.3.1 | Sedia Dokumen Pra-Kelayakan |  | 5d | 2018-03-21 | 2018-03-27 | 19 | 0d |  |
| 22 | 1.3.2 | Penyediaan Dokumen Pre-Bid | manual | 20d | 2018-03-21 | 2018-04-17 | 18 |  |  |
| 23 | 1.3.3 | Tawaran / Iklan Pra-Kelayakan |  | 12d | 2018-03-28 | 2018-04-12 | 21 | 0d |  |
| 24 | 1.3.4 | Penilaian Tawaran Pra-Kelayakan & Kelulusan |  | 10d | 2018-04-13 | 2018-04-26 | 23 | 0d |  |
| 25 | 1.3.5 | Tawaran Tender | manual | 45d | 2018-04-27 | 2018-06-28 | 22, 24 |  |  |
| 26 | 1.3.6 | Penilaian Tawaran | manual | 10d | 2018-06-29 | 2018-07-12 | 25 |  |  |
| 27 | 1.3.7 | Lembaga Tender |  | 10d | 2018-07-13 | 2018-07-26 | 26 | 0d |  |
| 28 | 1.3.8 | ATDA & Sah Peruntukan |  | 10d | 2018-07-27 | 2018-08-09 | 27 | 0d |  |
| 29 | 1.3.9 | Mengemukakan dan Penerimaan NCR Terhadap Cadangan Tender |  | 10d | 2018-08-10 | 2018-08-23 | 28 | 0d |  |
| 30 | 1.3.10 | Surat Setuju Terima Tender |  | 5d | 2018-08-24 | 2018-08-30 | 29 | 0d |  |
| 31 | 1.4 | Tamat Pra-Pembinaan | milestone | 0d | 2018-08-30 | 2018-08-30 | 30 | 0d |  |
